# eCom

Schedule from Planner, 2019-10-19 to 2020-06-16.

## Calendars

- Vorgabe: Mon-Sat 20:00-21:00; Sun off. Exceptions (off unless hours are given): 2019-10-20 20:00-21:00, 2019-11-18, 2019-12-23 20:00-21:00, 2019-12-24 to 2019-12-28, 2019-12-30 to 2020-01-01.

## Resources

| Resource |
| --- |
| Robin |
| Hannes |
| Lukas |
| Hendrik |
| Danny |
| Phillip |
| Jannik |

## Schedule

| ID | WBS | Task | Type | Duration | Start | Finish | Predecessors | Complete | Constraint | Resources | Work |
| --- | --- | --- | --- | --- | --- | --- | --- | --- | --- | --- | --- |
| 1 | 1 | **Project KickOff** |  |  | 2019-10-23 | 2019-11-05 |  |  | must start on 2019-10-30 |  | 3h |
| 2 | 1.1 | Charta überarbeiten |  |  | 2019-10-23 | 2019-11-05 |  | 100% | must start on 2019-10-23 | Jannik [25%] | 3h |
| 3 | 2 | **Lastenheft** |  |  | 2019-10-23 | 2019-12-10 |  |  | must start on 2019-12-11 |  | 111h |
| 4 | 2.1 | Dokumenten Koordinierung |  |  | 2019-10-23 | 2019-11-05 |  | 100% | start no earlier than 2019-10-23 | Lukas [25%] | 3h |
| 5 | 2.2 | Artikel bestellen (Endkunde) |  |  | 2019-10-23 | 2019-11-05 |  | 100% | start no earlier than 2019-10-23 | Phillip [34%] | 4h |
| 6 | 2.3 | Artikel bei Lieferant bestellen (Shop) |  |  | 2019-10-23 | 2019-11-05 |  | 100% | start no earlier than 2019-10-23 | Phillip [34%] | 4h |
| 7 | 2.4 | Lagerverwaltung |  |  | 2019-10-23 | 2019-11-05 |  | 100% | start no earlier than 2019-10-23 | Robin [50%] | 6h |
| 8 | 2.5 | Kundenverwaltung |  |  | 2019-10-23 | 2019-11-05 |  | 100% | start no earlier than 2019-10-23 | Hannes [50%] | 6h |
| 9 | 2.6 | Lieferantenverwaltung |  |  | 2019-10-23 | 2019-11-05 |  | 100% | start no earlier than 2019-10-23 | Hannes [50%] | 6h |
| 10 | 2.7 | Rabatt/Bonusprogramm für Endkunden |  |  | 2019-10-23 | 2019-11-05 |  | 100% | start no earlier than 2019-10-23 | Phillip [34%] | 4h |
| 11 | 2.8 | Status der Bestellung (Endkunde) |  |  | 2019-10-23 | 2019-11-05 |  | 100% | start no earlier than 2019-10-23 | Danny [50%] | 6h |
| 12 | 2.9 | Status der Lieferung an Betreiber des Shops |  |  | 2019-10-23 | 2019-11-05 |  | 100% | start no earlier than 2019-10-23 | Danny [50%] | 6h |
| 13 | 2.10 | Statistik Seite (Bestellungen, MwSt., Lagerbestände), täglich |  |  | 2019-10-23 | 2019-11-05 |  | 100% | start no earlier than 2019-10-23 | Hendrik [50%] | 6h |
| 14 | 2.11 | Einleitung, Ziel, Lieferumfang, Glosar |  |  | 2019-10-23 | 2019-11-05 |  | 100% | start no earlier than 2019-10-23 | Hendrik [50%] | 6h |
| 15 | 2.12 | Lastenheft 1. Draft | milestone | 0d | 2019-11-05 | 2019-11-05 | 14, 13, 12, 11, 10, 9, 8, 7, 6, 5, 4 |  |  |  |  |
| 16 | 2.13 | Überarbeitung Teil 1, Flussdiagramme |  |  | 2019-11-06 | 2019-11-20 | 15 | 100% |  | Robin [10%]; Hannes; Hendrik | 24h |
| 17 | 2.14 | Buchhaltung |  |  | 2019-11-20 | 2019-12-03 |  | 100% | must start on 2019-11-20 | Robin | 12h |
| 18 | 2.15 | NF Anforderungen überarbeiten |  |  | 2019-11-20 | 2019-12-03 |  | 100% | start no earlier than 2019-11-20 | Hendrik | 12h |
| 19 | 2.16 | Lastenheft änderungen umsetzen. |  |  | 2019-12-04 | 2019-12-10 |  | 100% | start no earlier than 2019-12-04 | Hendrik | 6h |
| 20 | 3 | **Glossar** |  |  | 2019-11-06 | 2019-11-12 |  |  | must start on 2019-11-13 |  | 6h |
| 21 | 3.1 | Glossar überarbeiten |  |  | 2019-11-06 | 2019-11-12 |  | 100% | start no earlier than 2019-11-06 | Lukas | 6h |
| 22 | 4 | **GUI Prototyp / Storyboards** |  |  | 2019-10-23 | 2020-03-11 |  |  | must start on 2020-02-12 |  | 300.5h |
| 23 | 4.1 | Webframework Technologie Recherche |  |  | 2019-10-23 | 2019-11-13 |  | 100% | start no earlier than 2019-10-23 | Jannik [66%] | 12h |
| 24 | 4.2 | Projekt Setup / Mini-Prototyp |  |  | 2019-11-13 | 2019-12-05 | 23 | 100% |  | Jannik | 18h |
| 25 | 4.3 | Liste mit Screens, welche Mockup wir brauchen |  |  | 2019-12-04 | 2020-01-02 |  | 100% | start no earlier than 2019-12-04 | Phillip; Jannik | 36h |
| 26 | 4.4 | Frontend Technologie Recherche (CSS) |  |  | 2019-11-06 | 2019-11-23 |  | 100% | start no earlier than 2019-11-06 | Robin [40%] | 6h |
| 27 | 4.5 | CSS weiter ausbauen |  |  | 2019-12-04 | 2019-12-17 |  | 100% | start no earlier than 2019-12-04 | Robin | 12h |
| 28 | 4.6 | Storyboard vorbereiten |  |  | 2020-01-02 | 2020-01-22 |  | 100% | must start on 2020-01-01 | Hendrik [50%] | 9h |

| ID | WBS | Task | Duration | Start | Finish | Complete | Constraint | Resources | Work |
| --- | --- | --- | --- | --- | --- | --- | --- | --- | --- |
| 29 | 4.7 | **GUI Prototyp** |  | 2020-01-02 | 2020-03-11 |  |  |  | 164.5h |
| 30 | 4.7.1 | UI: Frontpage überarbeiten |  | 2020-01-02 | 2020-01-22 | 100% | must start on 2020-01-01 | Hendrik [25%] | 4.5h |
| 31 | 4.7.2 | UI: About |  | 2020-01-02 | 2020-01-20 | 100% | must start on 2020-01-01 | Hendrik [25%] | 4h |
| 32 | 4.7.3 | UI: Header/Footer |  | 2020-01-02 | 2020-01-22 | 100% | must start on 2020-01-01 | Jannik [50%] | 9h |
| 33 | 4.7.4 | UI: Nutzerprofil |  | 2020-01-02 | 2020-01-22 | 100% | must start on 2020-01-01 | Jannik [50%] | 9h |
| 34 | 4.7.5 | UI: Shop (Suche, Detailansicht) |  | 2020-01-02 | 2020-01-22 | 100% | must start on 2020-01-01 | Hannes [50%] | 9h |
| 35 | 4.7.6 | UI: Checkout |  | 2020-01-02 | 2020-01-22 | 100% | must start on 2020-01-01 | Hannes [50%] | 9h |
| 36 | 4.7.7 | UI Betreiber: Seitenleiste |  | 2020-01-02 | 2020-01-22 | 100% | must start on 2020-01-01 | Danny [50%] | 9h |
| 37 | 4.7.8 | UI Betreiber: Dashboard |  | 2020-01-02 | 2020-01-22 | 100% | must start on 2020-01-01 | Danny [50%] | 9h |
| 38 | 4.7.9 | UI Betreiber: Verfügbare Artikel |  | 2020-01-02 | 2020-01-22 | 100% | must start on 2020-01-01 | Lukas [50%] | 9h |
| 39 | 4.7.10 | UI: Notifications |  | 2020-01-02 | 2020-01-22 | 100% | must start on 2020-01-01 | Lukas [50%] | 9h |
| 40 | 4.7.11 | UI Betreiber: Gelistete Artikel |  | 2020-01-02 | 2020-01-22 | 100% | start no earlier than 2020-01-01 | Robin [50%] | 9h |
| 41 | 4.7.12 | UI Betreiber: Interne Buchungen |  | 2020-01-02 | 2020-01-22 | 100% | must start on 2020-01-01 | Robin [50%] | 9h |
| 42 | 4.7.13 | UI Betreiber: Bestellungen (Kunden + Lieferanten) |  | 2020-01-02 | 2020-01-22 | 100% | start no earlier than 2020-01-01 | Phillip [50%] | 9h |
| 43 | 4.7.14 | UI Betreiber: Kunden + Lieferanten Liste |  | 2020-01-02 | 2020-01-22 | 100% | must start on 2020-01-01 | Phillip [50%] | 9h |
| 44 | 4.7.15 | UI Betreiber: Lager |  | 2020-01-22 | 2020-01-31 | 100% | must start on 2020-01-22 | Robin | 9h |
| 45 | 4.7.16 | UI Úberarbeiten und Vereinheitlichen | 2.25d | 2020-01-22 | 2020-02-11 | 100% | must start on 2020-01-22 | Robin [133%] | 24h |
| 46 | 4.7.17 | UI Prototyp auf Server deployen | 0.75d | 2020-02-10 | 2020-02-15 | 100% | must start on 2020-02-09 | Robin [50%] | 3h |
| 47 | 4.7.18 | UI Prototyp - Zurück Button implementieren. |  | 2020-02-26 | 2020-03-11 | 100% | must start on 2020-02-26 | Robin [33%] | 4h |
| 48 | 4.7.19 | UI Prototyp Bestätungsmeldungen |  | 2020-02-26 | 2020-03-11 | 100% | must start on 2020-02-26 | Robin [33%] | 4h |
| 49 | 4.7.20 | UI Prototyp Einkaufswagen überarbeiten |  | 2020-02-26 | 2020-03-11 | 100% | must start on 2020-02-26 | Robin [33%] | 4h |
| 50 | 4.8 | Storyboards erstellen und überarbeiten |  | 2020-01-22 | 2020-02-19 | 100% | must start on 2020-01-22 | Jannik | 25h |
| 51 | 4.9 | Prototyp für die verwendung des ORM implementieren |  | 2020-02-19 | 2020-03-10 | 100% | must start on 2020-02-19 | Jannik | 18h |
| 52 | 5 | **Risikoanalyse** |  | 2019-11-06 | 2020-01-28 |  | must start on 2020-02-12 |  | 36h |
| 53 | 5.1 | Produktrisiken: Lagerverwaltung + Algemein |  | 2019-11-06 | 2019-11-20 | 100% | start no earlier than 2019-11-06 | Phillip [50%] | 6h |
| 54 | 5.2 | Projektrisiken |  | 2019-11-06 | 2019-11-20 | 100% | start no earlier than 2019-11-06 | Phillip [50%] | 6h |
| 55 | 5.3 | Produktrisiken: Kundenverwaltung, Lieferverwaltung, Artikelverwaltung |  | 2019-11-06 | 2019-11-27 | 100% | must start on 2019-11-06 | Danny | 18h |
| 56 | 5.4 | Produktrisiken fertigstellen und überarbeiten |  | 2020-01-22 | 2020-01-28 | 100% | must start on 2020-01-22 | Phillip | 6h |

Notes:
- 46: Vermutlich Robin oder Lukas

| ID | WBS | Task | Start | Finish | Predecessors | Complete | Constraint | Resources | Work |
| --- | --- | --- | --- | --- | --- | --- | --- | --- | --- |
| 57 | 6 | **Projektplan** | 2019-10-23 | 2019-11-20 |  |  | must start on 2020-02-12 |  | 9h |
| 58 | 6.1 | Plan überarbeiten (Gnome Planner) | 2019-11-06 | 2019-11-20 |  | 100% | start no earlier than 2019-11-06 | Robin [50%] | 6h |
| 59 | 6.2 | Recherche: Projektplannungssoftware | 2019-10-23 | 2019-11-05 |  | 100% | must start on 2019-10-23 | Robin [25%] | 3h |
| 60 | 7 | **Pflichtenheft** | 2019-11-13 | 2020-03-10 |  |  | must start on 2020-03-11 |  | 187h |
| 61 | 7.1 | Vorbereiten, Mit Vorlage vergleichen | 2019-11-20 | 2019-11-26 | 15 | 100% | start no earlier than 2019-11-20 | Hannes | 6h |
| 62 | 7.2 | Muss-Kritierien von LH ableiten | 2019-11-27 | 2019-12-10 | 61 | 100% | start no earlier than 2019-11-20 | Hannes | 12h |
| 63 | 7.3 | Muss-Kriterien ausformulieren | 2019-12-11 | 2020-01-02 | 62 | 100% | must start on 2019-12-11 | Hannes | 12h |
| 64 | 7.4 | Wunsch Kriterien von LH ableiten | 2019-11-27 | 2019-12-10 |  | 100% | start no earlier than 2019-11-27 | Lukas | 12h |
| 65 | 7.5 | Wunsch Kriterien ausformulieren | 2019-12-11 | 2020-01-02 |  | 100% | start no earlier than 2019-12-11 | Lukas | 12h |
| 66 | 7.6 | Abgrenzungskriterien | 2019-11-13 | 2019-11-27 | 15 | 100% | start no earlier than 2019-11-13 | Lukas | 12h |
| 67 | 7.7 | Produkrisiken | 2019-12-11 | 2019-12-11 | 16, 15 | 100% | start no earlier than 2019-12-11 | Hendrik | 1h |
| 68 | 7.8 | Pflichtenheft Taskforce | 2020-01-22 | 2020-02-26 |  | 100% | must start on 2020-01-22 | Hannes; Lukas; Hendrik [75%] | 84h |
| 69 | 7.9 | Nachbestellung | 2020-02-26 | 2020-03-03 |  | 100% | must start on 2020-02-26 | Lukas | 6h |
| 70 | 7.10 | Buchaltung | 2020-02-26 | 2020-03-03 |  | 100% | must start on 2020-02-26 | Hannes | 6h |
| 71 | 7.11 | Feinschliff | 2020-03-04 | 2020-03-10 |  | 100% | must start on 2020-03-04 | Lukas | 6h |
| 72 | 7.12 | Fehlermeldungen überarbeiten (Dokumenten übergreifend) | 2020-02-26 | 2020-03-03 |  | 100% | must start on 2020-02-26 | Hendrik; Phillip | 12h |
| 73 | 7.13 | Fehlermeldungen Part 2 | 2020-03-04 | 2020-03-10 |  | 100% | must start on 2020-03-04 | Phillip | 6h |
| 74 | 8 | **Tracebillity Matrix** | 2020-01-22 | 2020-03-10 |  |  |  |  | 24h |
| 75 | 8.1 | Tracebillity Matrix [Verschoben] | 2020-01-22 | 2020-01-28 |  | 100% | must start on 2020-01-22 | Hendrik | 6h |
| 76 | 8.2 | Matrix Task Force | 2020-03-04 | 2020-03-10 |  | 100% | must start on 2020-03-04 | Hannes; Hendrik; Danny | 18h |
| 77 | 9 | **Mastertestplan** | 2019-11-27 | 2020-02-18 |  |  | must start on 2020-03-11 |  | 30h |
| 78 | 9.1 | Anlegen und Beginnen | 2019-11-27 | 2019-12-10 |  | 100% | start no earlier than 2019-11-27 | Danny | 12h |
| 79 | 9.2 | Ausarbeiten | 2020-01-29 | 2020-02-18 |  | 100% | start no earlier than 2020-01-29 | Phillip | 18h |
| 80 | 10 | **Systemtests** | 2019-11-20 | 2020-02-18 |  |  | must start on 2020-03-11 |  | 48h |
| 81 | 10.1 | Recherche: Teststategie für Webapps | 2019-12-11 | 2020-01-02 |  | 100% | start no earlier than 2019-12-11 | Danny | 12h |
| 82 | 10.2 | Systemtest vorbereiten | 2019-11-20 | 2019-12-03 |  | 100% | start no earlier than 2019-11-20 | Phillip | 12h |
| 83 | 10.3 | Systemtest fertigstellen | 2020-01-22 | 2020-02-18 |  | 100% | must start on 2020-01-22 | Danny | 24h |

| ID | WBS | Task | Start | Finish | Predecessors | Complete | Constraint | Resources | Work |
| --- | --- | --- | --- | --- | --- | --- | --- | --- | --- |
| 84 | 11 | **Grobdesign + Feindesign** | 2019-12-18 | 2020-05-12 |  |  |  |  | 296.44h |
| 85 | 11.1 | Grobes Datenschema | 2019-12-18 | 2020-01-09 |  | 100% | must start on 2019-12-18 | Robin | 12h |
| 86 | 11.2 | Datenbank Design I | 2020-02-26 | 2020-03-03 |  | 100% | must start on 2020-02-26 | Danny | 6h |
| 87 | 11.3 | Datenbank Design II | 2020-03-11 | 2020-04-08 |  | 100% | must start on 2020-03-11 | Hannes [20%]; Danny | 30h |
| 88 | 11.4 | Ergänzungen Datenbankschema | 2020-05-06 | 2020-05-12 | 111, 101, 91, 97, 96 | 75% | start no earlier than 2020-05-06 | Danny [50%] | 3h |
| 89 | 11.5 | Architekturmetting Kickoff | 2020-03-13 | 2020-03-14 |  | 100% | must start on 2020-03-13 | Robin; Lukas; Hendrik; Jannik | 8h |
| 90 | 11.6 | Feindesign Sendungsverfolgung | 2020-03-16 | 2020-04-09 | 89 | 100% | start no earlier than 2020-03-11 | Hannes [45%]; Phillip [50%]; Jannik [50%] | 31h |
| 91 | 11.7 | Feindesign Lieferanten | 2020-03-16 | 2020-04-09 | 89 | 100% |  | Hannes [45%]; Phillip [50%]; Jannik [50%] | 31h |
| 92 | 11.8 | **Modulaufteilung** | 2020-03-16 | 2020-05-05 |  |  |  |  | 11.44h |
| 93 | 11.8.1 | Grobdesign Modulaufteilung | 2020-03-16 | 2020-04-09 | 89 | 100% |  | Robin [25%] | 5.44h |
| 94 | 11.8.2 | Udpate bezüglich Actions & Controller | 2020-04-29 | 2020-05-05 |  | 100% | must start on 2020-04-29 | Hendrik | 6h |
| 95 | 11.9 | Feindesign Login System (mit Prototyp) | 2020-03-16 | 2020-04-09 | 89 | 100% |  | Robin [75%] | 16.5h |
| 96 | 11.10 | Feindesign Konfigurationsmanagement | 2020-03-16 | 2020-04-09 | 89 | 100% |  | Hendrik | 22h |
| 97 | 11.11 | Feindesign Artikelverwaltung | 2020-03-16 | 2020-04-09 | 89 | 90% |  | Lukas | 22h |
| 98 | 11.12 | Feindesign Cronjobs | 2020-04-09 | 2020-04-28 | 89 | 100% | start no earlier than 2020-04-09 | Lukas [50%] | 8.5h |
| 99 | 11.13 | Konzept zu Integrationstests | 2020-04-09 | 2020-04-22 |  | 100% | start no earlier than 2020-04-09 | Phillip | 12h |
| 100 | 11.14 | Konzept zu Suche | 2020-04-22 | 2020-04-28 |  | 100% | must start on 2020-04-22 | Hendrik | 6h |
| 101 | 11.15 | **Feindesign Actions und Controller** | 2020-04-08 | 2020-04-28 |  |  |  |  | 77h |
| 102 | 11.15.1 | Vorbereitung + Warehouse | 2020-04-08 | 2020-04-22 |  | 100% | must start on 2020-04-08 | Hannes | 13h |
| 103 | 11.15.2 | Login, Shop, Checkout | 2020-04-08 | 2020-04-22 |  | 100% | must start on 2020-04-08 | Robin | 13h |
| 104 | 11.15.3 | Artikel im Shop + Suche + Intern Buchungen | 2020-04-08 | 2020-04-22 |  | 100% | must start on 2020-04-08 | Hendrik | 12.5h |
| 105 | 11.15.4 | Intern Lieferanten + Intern Artikel | 2020-04-08 | 2020-04-22 |  | 100% | must start on 2020-04-08 | Danny | 13h |
| 106 | 11.15.5 | Nachbestellen + Cronjiobs | 2020-04-08 | 2020-04-22 |  | 100% | must start on 2020-04-08 | Lukas [50%] | 6.5h |
| 107 | 11.15.6 | Intern Nutzerverwaltung + Nutzereinstellungen | 2020-04-08 | 2020-04-22 |  | 100% | must start on 2020-04-08 | Jannik | 13h |
| 108 | 11.15.7 | Überarbeitung | 2020-04-22 | 2020-04-28 |  | 100% | must start on 2020-04-22 | Hannes | 6h |
| 109 | 12 | Integrationstests | 2020-04-22 | 2020-05-12 |  | 100% | must start on 2020-04-22 | Danny [90%]; Phillip | 34.2h |

| ID | WBS | Task | Start | Finish | Predecessors | Complete | Constraint | Resources | Work |
| --- | --- | --- | --- | --- | --- | --- | --- | --- | --- |
| 110 | 13 | **Implementierung** | 2020-04-22 | 2020-06-16 |  |  |  |  | 191.75h |
| 111 | 13.1 | DB Strukturen Anlegen und Überarbeiten | 2020-04-22 | 2020-04-28 |  | 100% | must start on 2020-04-22 | Robin | 5.75h |
| 112 | 13.2 | Packages und Controller anlegen | 2020-04-22 | 2020-04-28 |  | 100% | must start on 2020-04-22 | Jannik | 6h |
| 113 | 13.3 | Design Datenbank Index - Meeting + Ergänzung | 2020-05-20 | 2020-05-26 | 111, 102, 101 |  | start no earlier than 2020-05-20 |  | 6h |
| 114 | 13.4 | Checkout | 2020-04-29 | 2020-05-05 |  | 100% | must start on 2020-04-29 | Robin | 6h |
| 115 | 13.5 | Articles + Startpage | 2020-04-29 | 2020-05-12 |  | 75% | must start on 2020-04-29 | Hannes | 12h |
| 116 | 13.6 | Artikel hinzufügen (Intern) | 2020-05-06 | 2020-05-12 |  | 25% | must start on 2020-05-06 | Hendrik | 6h |
| 117 | 13.7 | Lieferanten Service | 2020-05-06 | 2020-05-19 |  |  | must start on 2020-05-06 | Robin | 12h |
| 118 | 13.8 | Cron + Autonachbestellen | 2020-05-06 | 2020-05-19 |  | 10% | must start on 2020-05-06 | Lukas | 12h |
| 119 | 13.9 | Code Review + Hilfestellung | 2020-04-29 | 2020-05-26 |  | 75% | must start on 2020-04-29 | Jannik | 24h |
| 120 | 13.10 | Login überarbeiten + CSFR | 2020-05-20 | 2020-05-26 |  |  | start no earlier than 2020-05-20 |  | 6h |
| 121 | 13.11 | Suche | 2020-05-13 | 2020-05-19 |  |  | must start on 2020-05-13 |  | 6h |
| 122 | 13.12 | Intern Warehouse | 2020-05-13 | 2020-05-26 |  |  | must start on 2020-05-13 |  | 12h |
| 123 | 13.13 | Intern Buchungen | 2020-05-20 | 2020-06-02 |  |  | start no earlier than 2020-05-20 |  | 12h |
| 124 | 13.14 | Customer + Order | 2020-05-20 | 2020-06-02 |  |  | start no earlier than 2020-05-20 |  | 12h |
| 125 | 13.15 | Supplier + Order | 2020-05-27 | 2020-06-09 |  |  | must start on 2020-05-27 |  | 12h |
| 126 | 13.16 | Nutzersettings | 2020-05-27 | 2020-06-16 |  |  | must start on 2020-05-27 |  | 18h |
| 127 | 13.17 | Dashboard | 2020-06-03 | 2020-06-16 |  |  | must start on 2020-06-03 |  | 12h |
| 128 | 13.18 | Sendungsverfolgung | 2020-06-03 | 2020-06-16 |  |  | must start on 2020-06-03 |  | 12h |
| 129 | 14 | **Orga** | 2019-10-19 | 2020-05-05 |  |  |  |  | 15h |
| 130 | 14.1 | Infrastruktur und Wiki einrichten | 2019-10-19 | 2019-10-20 |  | 100% | must start on 2019-10-16 | Hendrik [150%] | 3h |
| 131 | 14.2 | Templates anlegen für Google Doc | 2019-10-23 | 2019-11-05 |  | 100% | start no earlier than 2019-10-23 | Robin [25%] | 3h |
| 132 | 14.3 | Recherche zu Code Formatter | 2019-10-23 | 2019-11-05 |  | 100% | must start on 2019-10-23 | Lukas [25%] | 3h |
| 133 | 14.4 | Anpassung durch Streichung | 2020-04-29 | 2020-05-05 |  | 100% | must start on 2020-04-29 | Lukas | 6h |
